# DORISS_PUP_04_rev1

Schedule from MS Project, 2004-01-15 to 2004-09-29.
MBARI

## Calendars

- Standard: Mon-Fri 08:00-12:00, 13:00-17:00; Sat-Sun off.

## Resources

| Resource |
| --- |
| Karen Salamy |
| Sheri White |
| Rich Henthorn |
| Alana Sherman |
| Sheri White? |
| ON HOLD for Now |
| On Hold |
| EE Tech |
| Scott Jensen |
| Mark Brown |
| Johnny F |
| Jim Scholfield |
| Buck R |
| Mark B |
| Jonnhy F |
| Johnnny F |
| Bill K |
| ?? |
| Sheri W |
| Ventana |
| Tiburon |

## Schedule

| ID | WBS | Task | Duration | Start | Finish | Predecessors | Total slack | Free slack | Constraint | Resources | Work |
| --- | --- | --- | --- | --- | --- | --- | --- | --- | --- | --- | --- |
| 1 | 1 | **DORISS/PUP Overview** | 185d? | 2004-01-15 | 2004-09-29 |  | 0d |  |  |  | 10640.6h |
| 2 | 1.1 | **Current Work / Repairs** | 148.37d? | 2004-01-15 | 2004-08-10 |  | 36.63d |  |  |  | 4972.64h |
| 4 | 1.1.1 | **DORISS** | 23d? | 2004-01-19 | 2004-02-18 |  | 160d |  |  |  | 904h |
| 5 | 1.1.1.1 | Networking | 11d? | 2004-01-22 | 2004-02-05 |  | 169d |  | start no earlier than 2004-01-22 | Karen Salamy; Sheri White | 176h |
| 6 | 1.1.1.2 | Fix LRS Client-single IP | 12.5d? | 2004-01-26 | 2004-02-11 |  | 165.5d |  | start no earlier than 2004-01-26 | Karen Salamy; Rich Henthorn | 200h |
| 7 | 1.1.1.3 | Alternatives to Net Meeting | 18d | 2004-01-26 | 2004-02-18 |  | 160d |  | start no earlier than 2004-01-26 | Karen Salamy; Rich Henthorn | 288h |
| 8 | 1.1.1.4 | Clean up wiring in Housing | 7d | 2004-01-19 | 2004-01-27 |  | 176d |  |  | Alana Sherman; EE Tech | 112h |
| 9 | 1.1.1.5 | repair camera cable | 8d | 2004-01-21 | 2004-01-30 |  | 173d |  | finish no earlier than 2004-01-30 | Alana Sherman; Sheri White? | 128h |
| 11 | 1.1.2 | **PUP** | 148.37d? | 2004-01-15 | 2004-08-10 |  | 36.63d |  |  |  | 4068.64h |
| 12 | 1.1.2.1 | Check for Electronic room for Z-axis | 6.67d | 2004-01-15 | 2004-01-23 |  | 36.63d | 0d | start no earlier than 2004-01-15 | Alana Sherman [15%]; Scott Jensen [15%] | 16h |
| 13 | 1.1.2.2 | **Switch Dovetail assemblies** | 4d? | 2004-01-19 | 2004-01-22 |  | 179d |  |  | ON HOLD for Now | 64h |
| 14 | 1.1.2.2.1 | Test in pressure chamber | 1d? | 2004-01-19 | 2004-01-19 |  | 179d | 0d |  | On Hold | 8h |
| 15 | 1.1.2.2.2 | Test in cold room | 1d? | 2004-01-20 | 2004-01-20 | 14 | 179d | 0d |  | On Hold | 8h |
| 16 | 1.1.2.2.3 | Test in test tank | 1d? | 2004-01-21 | 2004-01-21 | 15 | 179d | 0d |  | On Hold | 8h |
| 17 | 1.1.2.2.4 | Test at Sea | 1d? | 2004-01-22 | 2004-01-22 | 16 | 179d |  |  | On Hold | 8h |
| 18 | 1.1.2.3 | **Fix Z-axis Limit Switch** | 49.5d? | 2004-01-22 | 2004-03-31 |  | 130.5d |  |  |  | 792h |
| 19 | 1.1.2.3.1 | check current limit switch | 5d | 2004-01-22 | 2004-01-28 |  | 170d | 0d | finish no earlier than 2004-01-28 | Alana Sherman; EE Tech | 80h |
| 20 | 1.1.2.3.2 | check spare limit switch | 8.5d? | 2004-01-29 | 2004-02-10 | 19 | 130.5d | 0d |  | Alana Sherman; EE Tech | 136h |
| 21 | 1.1.2.3.3 | check wiring | 7.5d? | 2004-02-10 | 2004-02-19 | 20 | 130.5d | 0d |  | Alana Sherman; EE Tech | 120h |
| 22 | 1.1.2.3.4 | test in lab | 14.5d? | 2004-02-20 | 2004-03-11 | 21 | 130.5d | 0d |  | Alana Sherman; EE Tech | 232h |
| 23 | 1.1.2.3.5 | test in cold room | 8.5d? | 2004-03-11 | 2004-03-23 | 22 | 130.5d | 0d |  | Alana Sherman; EE Tech | 136h |
| 24 | 1.1.2.3.6 | test in test tank | 5.5d? | 2004-03-24 | 2004-03-31 | 23 | 130.5d |  |  | Alana Sherman; EE Tech | 88h |
| 25 | 1.1.2.4 | **Theta axis** | 141.7d? | 2004-01-23 | 2004-08-10 | 12 | 36.63d |  |  |  | 610.64h |
| 26 | 1.1.2.4.1 | design | 102.2d? | 2004-01-23 | 2004-06-15 |  | 36.63d | 0d |  | Mark Brown [15%] | 122.64h |
| 27 | 1.1.2.4.2 | review | 1d? | 2004-06-15 | 2004-06-16 | 26 | 36.63d | 0d | start no earlier than 2004-02-16 | Mark Brown | 8h |
| 28 | 1.1.2.4.3 | build | 5.5d? | 2004-06-16 | 2004-06-24 | 27 | 36.63d | 0d |  | Mark Brown; Johnny F | 88h |
| 29 | 1.1.2.4.4 | assemble / install | 6.5d? | 2004-06-24 | 2004-07-02 | 28 | 36.63d | 0d |  | Mark Brown; Johnny F | 104h |
| 30 | 1.1.2.4.5 | test in lab | 4d? | 2004-07-02 | 2004-07-08 | 29 | 36.63d | 0d |  | Mark Brown; Johnny F | 64h |
| 31 | 1.1.2.4.6 | test in tank | 7d? | 2004-07-08 | 2004-07-19 | 30 | 36.63d | 0d |  | Mark Brown; Johnny F | 112h |
| 32 | 1.1.2.4.7 | test in cold room | 7d? | 2004-07-19 | 2004-07-28 | 31 | 36.63d | 0d |  | Mark Brown; Johnny F | 112h |
| 33 | 1.1.2.4.8 | At sea testing | 8.5d? | 2004-07-28 | 2004-08-10 | 32 | 36.63d |  |  |  |  |

Notes:
- 13: ON HOLD for Now

| ID | WBS | Task | Duration | Start | Finish | Predecessors | Total slack | Free slack | Constraint | Resources | Work |
| --- | --- | --- | --- | --- | --- | --- | --- | --- | --- | --- | --- |
| 34 | 1.1.2.5 | **Install new LED light** | 40d? | 2004-01-19 | 2004-03-12 |  | 143d |  |  |  | 608h |
| 35 | 1.1.2.5.1 | purchase LEDs | 15d? | 2004-01-19 | 2004-02-06 |  | 143d | 0d |  | Scott Jensen | 120h |
| 36 | 1.1.2.5.2 | pot LEDs | 14d? | 2004-02-09 | 2004-02-26 | 35 | 143d | 0d |  | Scott Jensen; Jim Scholfield | 224h |
| 37 | 1.1.2.5.3 | test in test tank | 11d? | 2004-02-27 | 2004-03-12 | 36 | 143d |  |  | Scott Jensen; Alana Sherman; Jim Scholfield | 264h |
| 38 | 1.1.2.6 | **New Probe head mount** | 139d? | 2004-01-19 | 2004-07-29 |  | 44d |  |  |  | 698h |
| 39 | 1.1.2.6.1 | Design | 100d? | 2004-01-19 | 2004-06-04 |  | 44d | 0d |  | Mark Brown [20%] | 154h |
| 40 | 1.1.2.6.2 | Build | 15d? | 2004-06-07 | 2004-06-25 | 39 | 44d | 0d |  | Mark Brown; Jonnhy F | 240h |
| 41 | 1.1.2.6.3 | Assemble | 10d? | 2004-06-28 | 2004-07-09 | 40 | 44d | 0d |  | Johnny F | 80h |
| 42 | 1.1.2.6.4 | Vertical testing | 8d? | 2004-07-12 | 2004-07-21 | 41 | 44d | 0d |  | Sheri White; Johnny F | 128h |
| 43 | 1.1.2.6.5 | Test in cold room | 6d? | 2004-07-22 | 2004-07-29 | 42 | 44d |  |  | Sheri White; Johnnny F | 96h |
| 44 | 1.1.2.7 | **Adjust camera server rate** | 13.5d? | 2004-01-19 | 2004-02-05 |  | 169.5d |  |  |  | 216h |
| 45 | 1.1.2.7.1 | Reduce ethernet traffic | 13.5d? | 2004-01-19 | 2004-02-05 |  | 169.5d |  |  | Rich Henthorn; Alana Sherman | 216h |
| 46 | 1.1.2.8 | **Z-axis Rt Angle connector** | 49.5d? | 2004-01-19 | 2004-03-26 |  | 133.5d |  |  |  | 456h |
| 47 | 1.1.2.8.1 | Order | 33.5d? | 2004-01-19 | 2004-03-04 |  | 133.5d | 0d |  | Scott Jensen | 268h |
| 48 | 1.1.2.8.2 | Installation | 8.5d? | 2004-03-04 | 2004-03-16 | 47 | 133.5d | 0d |  | EE Tech | 68h |
| 49 | 1.1.2.8.3 | Test | 7.5d? | 2004-03-17 | 2004-03-26 | 48 | 133.5d |  |  | Scott Jensen; EE Tech | 120h |
| 50 | 1.1.2.9 | **Swing Arm** | 59d? | 2004-01-29 | 2004-04-20 |  | 116d |  |  |  | 608h |
| 51 | 1.1.2.9.1 | Consult on Design | 24d? | 2004-01-29 | 2004-03-02 |  | 116d | 0d | start no earlier than 2004-01-29 | Mark Brown [4.2%] | 8h |
| 52 | 1.1.2.9.2 | Build | 15d? | 2004-03-03 | 2004-03-23 | 51 | 116d | 0d |  | Johnny F | 120h |
| 53 | 1.1.2.9.3 | Test | 20d? | 2004-03-24 | 2004-04-20 | 52 | 116d |  |  | Johnny F; Buck R; Mark B | 480h |
| 55 | 1.2 | **Upgrades** | 173d? | 2004-01-19 | 2004-09-15 |  | 10d |  |  |  | 5476h |
| 56 | 1.2.1 | **Purchase new components** | 46d? | 2004-01-19 | 2004-03-22 |  | 137d |  |  |  | 1464h |
| 57 | 1.2.1.1 | USB CCD camera | 46d? | 2004-01-19 | 2004-03-22 |  | 137d |  |  | Sheri W | 368h |
| 58 | 1.2.1.2 | MR Probe head | 46d? | 2004-01-19 | 2004-03-22 |  | 137d |  |  | Sheri W | 368h |
| 59 | 1.2.1.3 | Titanium immersion probe | 46d? | 2004-01-19 | 2004-03-22 |  | 137d |  |  | Sheri W | 368h |
| 60 | 1.2.1.4 | 532 nm laser | 45d? | 2004-01-19 | 2004-03-19 |  | 138d |  |  | Sheri W | 360h |

| ID | WBS | Task | Duration | Start | Finish | Predecessors | Total slack | Free slack | Resources | Work |
| --- | --- | --- | --- | --- | --- | --- | --- | --- | --- | --- |
| 62 | 1.2.2 | **DORISS** | 166d? | 2004-01-19 | 2004-09-06 |  | 17d |  |  | 2692h |
| 63 | 1.2.2.1 | **New optical bench** | 114d? | 2004-01-19 | 2004-06-24 |  | 69d |  |  | 1488h |
| 64 | 1.2.2.1.1 | design | 30d? | 2004-01-19 | 2004-02-27 |  | 69d | 0d | Bill K | 240h |
| 65 | 1.2.2.1.2 | PDR | 8d? | 2004-03-01 | 2004-03-10 | 64 | 69d | 0d | Bill K | 64h |
| 66 | 1.2.2.1.3 | build | 6.5d? | 2004-03-11 | 2004-03-19 | 65 | 69d | 0d | ?? | 52h |
| 67 | 1.2.2.1.4 | bench assembly | 13d? | 2004-03-19 | 2004-04-07 | 66 | 69d | 0d | Bill K; Sheri W | 208h |
| 68 | 1.2.2.1.5 | test | 10d? | 2004-04-07 | 2004-04-21 | 67 | 69d | 0d | Sheri W; Bill K; Alana Sherman | 240h |
| 69 | 1.2.2.1.6 | housing mods | 7.5d? | 2004-04-21 | 2004-04-30 | 68 | 69d | 0d | Bill K | 60h |
| 70 | 1.2.2.1.7 | optical sub-assembly | 9.5d? | 2004-05-03 | 2004-05-14 | 69 | 69d | 0d | Sheri W; Alana Sherman | 152h |
| 71 | 1.2.2.1.8 | sub-system test | 9.5d? | 2004-05-14 | 2004-05-27 | 70 | 69d | 0d | Sheri W; Alana Sherman | 152h |
| 72 | 1.2.2.1.9 | optical sys complete tets | 9d? | 2004-05-28 | 2004-06-09 | 71 | 69d | 0d | Sheri W; Alana Sherman | 144h |
| 73 | 1.2.2.1.10 | tank test | 11d? | 2004-06-10 | 2004-06-24 | 72 | 69d |  | Sheri W; Alana Sherman | 176h |
| 74 | 1.2.2.2 | **New Housings** | 166d? | 2004-01-19 | 2004-09-06 |  | 17d |  |  | 1204h |
| 75 | 1.2.2.2.1 | **Spectrometer housing** | 52d? | 2004-03-11 | 2004-05-21 |  | 93d |  |  | 544h |
| 76 | 1.2.2.2.1.1 | design | 12d? | 2004-03-11 | 2004-03-26 | 65 | 93d | 0d | Mark Brown | 96h |
| 77 | 1.2.2.2.1.2 | review | 14d? | 2004-03-29 | 2004-04-15 | 76 | 93d | 0d | Mark Brown | 112h |
| 78 | 1.2.2.2.1.3 | build | 9d? | 2004-04-16 | 2004-04-28 | 77 | 93d | 0d | Mark Brown; Johnny F | 144h |
| 79 | 1.2.2.2.1.4 | assemble | 10d? | 2004-04-29 | 2004-05-12 | 78 | 93d | 0d | Johnny F | 80h |
| 80 | 1.2.2.2.1.5 | test | 7d? | 2004-05-13 | 2004-05-21 | 79 | 93d |  | Mark Brown; Johnny F | 112h |
| 81 | 1.2.2.2.2 | **Probe Head housing** | 166d? | 2004-01-19 | 2004-09-06 |  | 17d |  |  | 660h |
| 82 | 1.2.2.2.2.1 | design | 120d? | 2004-01-19 | 2004-07-02 |  | 17d | 0d | Mark Brown [20%] | 192h |
| 83 | 1.2.2.2.2.2 | review | 15d? | 2004-07-05 | 2004-07-23 | 82 | 17d | 0d | Mark Brown | 120h |
| 84 | 1.2.2.2.2.3 | build | 9d? | 2004-07-26 | 2004-08-05 | 83 | 17d | 0d | Johnny F | 72h |
| 85 | 1.2.2.2.2.4 | assemble | 9.5d? | 2004-08-06 | 2004-08-19 | 84 | 17d | 0d | Johnny F | 76h |
| 86 | 1.2.2.2.2.5 | test | 12.5d? | 2004-08-19 | 2004-09-06 | 85 | 17d |  | Mark Brown; Johnny F | 200h |

| ID | WBS | Task | Duration | Start | Finish | Predecessors | Total slack | Free slack | Constraint | Resources | Work |
| --- | --- | --- | --- | --- | --- | --- | --- | --- | --- | --- | --- |
| 87 | 1.2.3 | **PUP** | 173d? | 2004-01-19 | 2004-09-15 |  | 10d |  |  |  | 1320h |
| 88 | 1.2.3.1 | **Add pan & tilt 2 degrees of freedom** | 173d? | 2004-01-19 | 2004-09-15 |  | 10d |  |  |  | 1320h |
| 89 | 1.2.3.1.1 | Verify drive electronics fit | 12.5d? | 2004-01-19 | 2004-02-04 |  | 10d | 0d |  | Alana Sherman | 100h |
| 90 | 1.2.3.1.2 | Design | 75d? | 2004-02-04 | 2004-05-19 | 89 | 10d | 0d |  | Mark Brown [20%] | 120h |
| 91 | 1.2.3.1.3 | Design Review | 16d? | 2004-05-19 | 2004-06-10 | 90 | 10d | 0d |  | Mark Brown | 128h |
| 92 | 1.2.3.1.4 | Build | 10.5d? | 2004-06-10 | 2004-06-24 | 91 | 10d | 0d |  | Mark Brown; Johnny F | 168h |
| 93 | 1.2.3.1.5 | Assemble | 17.5d? | 2004-06-25 | 2004-07-20 | 92 | 10d | 0d |  | Johnny F | 140h |
| 94 | 1.2.3.1.6 | Lab test | 11d? | 2004-07-20 | 2004-08-04 | 93 | 10d | 0d |  | Mark Brown; Johnny F | 176h |
| 95 | 1.2.3.1.7 | Tank test | 15d? | 2004-08-04 | 2004-08-25 | 94 | 10d | 0d |  | Mark Brown; Johnny F | 240h |
| 96 | 1.2.3.1.8 | Cold Test | 15.5d? | 2004-08-25 | 2004-09-15 | 95 | 10d |  |  | Mark Brown; Johnny F | 248h |
| 98 | 1.3 | **Cruises** | 142d? | 2004-03-16 | 2004-09-29 |  | 0d |  |  |  | 192h |
| 99 | 1.3.1 | March 17-18 - Ventana | 4d? | 2004-03-16 | 2004-03-19 |  | 138d |  | start no earlier than 2004-03-16 | Ventana | 32h |
| 100 | 1.3.2 | March 19-22 - Ventana | 3d? | 2004-03-19 | 2004-03-23 |  | 136d |  | start no earlier than 2004-03-19 | Ventana | 24h |
| 101 | 1.3.3 | July 14-26 - Tiburon / Hydrate Ridge | 13d? | 2004-07-13 | 2004-07-29 |  | 44d |  | start no earlier than 2004-07-13 | Tiburon | 104h |
| 102 | 1.3.4 | Spet 27-28 - Ventana | 4d? | 2004-09-24 | 2004-09-29 |  | 0d |  | start no earlier than 2004-09-24 | Ventana | 32h |
