# DORISS_PUP_04_rev7

Schedule from MS Project, 2004-01-15 to 2004-06-24, costs in $, A marks actual dates.
MBARI

## Calendars

- Standard: Mon-Fri 08:00-12:00, 13:00-17:00; Sat-Sun off.

## Resources

| Resource |
| --- |
| Karen Salamy |
| Sheri White |
| Rich Henthorn |
| Alana Sherman |
| Sheri White? |
| ON HOLD for Now |
| On Hold |
| EE Tech |
| Scott Jensen |
| Mark Brown |
| Johnny F |
| Jim Scholfield |
| Buck R |
| Mark B |
| Jonnhy F |
| Johnnny F |
| Bill K |
| ?? |
| Sheri W |
| Ventana |
| Tiburon |

## Schedule

| ID | WBS | Task | Duration | Start | Finish | Predecessors | Complete | Remaining | Total slack | Free slack | Constraint | Resources | Work | Actual work | Cost | Actual cost |
| --- | --- | --- | --- | --- | --- | --- | --- | --- | --- | --- | --- | --- | --- | --- | --- | --- |
| 1 | 1 | **DORISS/PUP Overview** | 116d? | 2004-01-15 A | 2004-06-24 |  | 8% | 106.22d? | 69d |  |  |  | 9146.64h | 672.96h | 116,950 | 6,609.5 |
| 2 | 1.1 | **125) 2004 Publications** | 1d? | 2004-01-19 A | 2004-01-19 |  |  | 1d? | 113d |  |  |  |  |  |  |  |
| 3 | 1.1.1 | 126) 2004 AGU | 1d? | 2004-01-19 | 2004-01-19 |  |  |  | 182d |  |  |  |  |  |  |  |
| 4 | 1.1.2 | 127) Oceans 2004 ? | 1d? | 2004-01-19 | 2004-01-19 |  |  |  | 182d |  |  |  |  |  |  |  |
| 5 | 1.1.3 | 128) DSR Journal paper on PUP technology | 1d? | 2004-01-19 A | 2004-01-19 |  | 1% | 0.99d? | 182d |  |  |  |  |  |  |  |
| 6 | 1.2 | **Current Work / Repairs** | 61.5d? | 2004-01-15 A | 2004-04-09 |  | 16% | 51.59d? | 54.5d |  |  |  | 5210.64h | 649.13h | 10,000 |  |
| 8 | 1.2.1 | **DORISS** | 23d? | 2004-01-19 A | 2004-02-18 |  | 40% | 13.87d? | 91d |  |  |  | 904h | 349.2h |  |  |
| 9 | 1.2.1.1 | 1) Networking - Ventana | 11d? | 2004-01-22 A | 2004-02-05 |  | 10% | 9.9d? | 169d |  | start no earlier than 2004-01-22 | Karen Salamy; Sheri White | 176h | 17.6h |  |  |
| 10 | 1.2.1.2 | 2) Fix LRS Client-single IP | 12.5d? | 2004-01-26 A | 2004-02-11 |  | 25% | 9.38d? | 165.5d |  | start no earlier than 2004-01-26 | Karen Salamy; Rich Henthorn | 200h | 50h |  |  |
| 11 | 1.2.1.3 | 3) Resetting IP Addresses | 1d? | 2004-01-19 A | 2004-01-19 A |  | 100% |  |  |  |  |  |  |  |  |  |
| 12 | 1.2.1.4 | 4) Alternatives to Net Meeting | 18d | 2004-01-26 A | 2004-02-18 |  | 50% | 9d | 160d |  | start no earlier than 2004-01-26 | Karen Salamy; Rich Henthorn | 288h | 144h |  |  |
| 13 | 1.2.1.5 | 5) Clean up wiring in Housing | 7d | 2004-01-19 A | 2004-01-27 A |  | 100% |  |  |  |  | Alana Sherman; EE Tech | 112h | 112h |  |  |
| 14 | 1.2.1.6 | 6) Repair camera cable | 8d | 2004-01-21 A | 2004-01-30 |  | 20% | 6.4d | 173d |  | finish no earlier than 2004-01-30 | Alana Sherman; Sheri White? | 128h | 25.6h |  |  |
| 16 | 1.2.2 | **PUP** | 61.5d? | 2004-01-15 A | 2004-04-09 |  | 12% | 53.98d? | 54.5d |  |  |  | 4306.64h | 299.93h | 10,000 |  |
| 17 | 1.2.2.1 | **129) Vic Wiring and PUP Gui Mods** | 1d? | 2004-01-19 A | 2004-01-19 |  | 60% | 0.4d? | 113d |  |  |  |  |  |  |  |
| 18 | 1.2.2.1.1 | 130) Vic Wiring | 1d? | 2004-01-19 A | 2004-01-19 A |  | 100% |  |  |  |  |  |  |  |  |  |
| 19 | 1.2.2.1.2 | 131) PUP GUI Mods | 1d? | 2004-01-19 A | 2004-01-19 |  | 20% | 0.8d? | 182d |  |  |  |  |  |  |  |
| 20 | 1.2.2.2 | 7) Check for Electronic room for Z-axis | 6.67d | 2004-01-15 A | 2004-01-23 A |  | 100% |  |  |  | start no earlier than 2004-01-15 | Alana Sherman [15%]; Scott Jensen [15%] | 16h | 16h |  |  |
| 21 | 1.2.2.3 | **8) Switch Dovetail assemblies** | 4d? | 2004-01-19 | 2004-01-22 |  |  |  | 110d |  |  | ON HOLD for Now | 64h |  |  |  |
| 22 | 1.2.2.3.1 | 9) Test in pressure chamber | 1d? | 2004-01-19 | 2004-01-19 |  |  |  | 179d | 0d |  | On Hold | 8h |  |  |  |
| 23 | 1.2.2.3.2 | 10) Test in cold room | 1d? | 2004-01-20 | 2004-01-20 | 22 |  |  | 179d | 0d |  | On Hold | 8h |  |  |  |
| 24 | 1.2.2.3.3 | 11) Test in test tank | 1d? | 2004-01-21 | 2004-01-21 | 23 |  |  | 179d | 0d |  | On Hold | 8h |  |  |  |
| 25 | 1.2.2.3.4 | 12) Test at Sea | 1d? | 2004-01-22 | 2004-01-22 | 24 |  |  | 179d |  |  | On Hold | 8h |  |  |  |
| 26 | 1.2.2.4 | **13) Fix Z-axis Limit Switch** | 52.5d? | 2004-01-19 A | 2004-03-31 |  | 4% | 50.16d? | 61.5d |  |  |  | 816h | 35.2h |  |  |
| 27 | 1.2.2.4.1 | 14) check current limit switch | 5d | 2004-01-22 A | 2004-01-28 |  | 10% | 4.5d | 132.1d | 0d | finish no earlier than 2004-01-28 | Alana Sherman; EE Tech | 80h | 8h |  |  |
| 28 | 1.2.2.4.2 | 15) check spare limit switch | 8.5d? | 2004-01-29 A | 2004-02-10 | 27 | 10% | 7.65d? | 131.25d | 0d |  | Alana Sherman; EE Tech | 136h | 13.6h |  |  |
| 29 | 1.2.2.4.3 | 16) check wiring | 7.5d? | 2004-02-10 A | 2004-02-19 | 28 | 10% | 6.75d? | 130.5d | 0d |  | Alana Sherman; EE Tech | 120h | 12h |  |  |
| 30 | 1.2.2.4.4 | 17) test in lab | 14.5d? | 2004-02-20 | 2004-03-11 | 29 |  |  | 130.5d | 0d |  | Alana Sherman; EE Tech | 232h |  |  |  |
| 31 | 1.2.2.4.5 | 18) test in cold room | 8.5d? | 2004-03-11 | 2004-03-23 | 30 |  |  | 130.5d | 0d |  | Alana Sherman; EE Tech | 136h |  |  |  |
| 32 | 1.2.2.4.6 | 19) test in test tank | 5.5d? | 2004-03-24 | 2004-03-31 | 31 |  |  | 130.5d |  |  | Alana Sherman; EE Tech | 88h |  |  |  |
| 33 | 1.2.2.4.7 | 20) Exlar Discussion on Limit Switch | 1d? | 2004-01-19 A | 2004-01-19 |  | 20% | 0.8d? | 182d |  |  | Mark B | 8h | 1.6h |  |  |
| 34 | 1.2.2.4.8 | 21) Test Matrix | 1d? | 2004-01-19 | 2004-01-19 |  |  |  | 182d |  |  | Alana Sherman; Mark B | 16h |  |  |  |

Notes:
- 21: ON HOLD for Now

| ID | WBS | Task | Duration | Start | Finish | Predecessors | Complete | Remaining | Total slack | Free slack | Constraint | Resources | Work | Actual work | Cost |
| --- | --- | --- | --- | --- | --- | --- | --- | --- | --- | --- | --- | --- | --- | --- | --- |
| 35 | 1.2.2.5 | **22) Theta axis** | 54.83d? | 2004-01-23 A | 2004-04-09 | 20 | 2% | 53.96d? | 54.5d |  |  |  | 634.64h | 7.33h | 10,000 |
| 36 | 1.2.2.5.1 | 23) Alternative Concepts | 3d? | 2004-01-23 A | 2004-01-28 |  | 5% | 2.85d? | 175.28d |  |  | Mark Brown | 24h | 1.2h |  |
| 37 | 1.2.2.5.2 | 24) design | 15.33d? | 2004-01-23 A | 2004-02-13 |  | 5% | 14.56d? | 123.5d | 0d |  | Mark Brown | 122.64h | 6.13h |  |
| 38 | 1.2.2.5.3 | 25) review | 1d? | 2004-02-16 | 2004-02-16 | 37 |  |  | 123.5d | 0d | start no earlier than 2004-02-16 | Mark Brown | 8h |  |  |
| 39 | 1.2.2.5.4 | 26) build | 5.5d? | 2004-02-17 | 2004-02-24 | 38 |  |  | 123.5d | 0d |  | Mark Brown; Johnny F | 88h |  | 10,000 |
| 40 | 1.2.2.5.5 | 27) assemble / install | 6.5d? | 2004-02-24 | 2004-03-03 | 39 |  |  | 123.5d | 0d |  | Mark Brown; Johnny F | 104h |  |  |
| 41 | 1.2.2.5.6 | 28) test in lab | 4d? | 2004-03-04 | 2004-03-09 | 40 |  |  | 123.5d | 0d |  | Mark Brown; Johnny F | 64h |  |  |
| 42 | 1.2.2.5.7 | 29) test in tank | 7d? | 2004-03-10 | 2004-03-18 | 41 |  |  | 123.5d | 0d |  | Mark Brown; Johnny F | 112h |  |  |
| 43 | 1.2.2.5.8 | 30) test in cold room | 7d? | 2004-03-19 | 2004-03-29 | 42 |  |  | 123.5d | 0d |  | Mark Brown; Johnny F | 112h |  |  |
| 44 | 1.2.2.5.9 | 31) At sea testing | 8.5d? | 2004-03-30 | 2004-04-09 | 43 |  |  | 123.5d |  |  |  |  |  |  |
| 45 | 1.2.2.6 | **32) Install new LED light** | 40d? | 2004-01-19 | 2004-03-12 |  |  |  | 74d |  |  |  | 608h |  |  |
| 46 | 1.2.2.6.1 | 33) purchase LEDs | 15d? | 2004-01-19 | 2004-02-06 |  |  |  | 143d | 0d |  | Scott Jensen | 120h |  |  |
| 47 | 1.2.2.6.2 | 34) pot LEDs | 14d? | 2004-02-09 | 2004-02-26 | 46 |  |  | 143d | 0d |  | Scott Jensen; Jim Scholfield | 224h |  |  |
| 48 | 1.2.2.6.3 | 35) test in test tank | 11d? | 2004-02-27 | 2004-03-12 | 47 |  |  | 143d |  |  | Scott Jensen; Alana Sherman; Jim Scholfield | 264h |  |  |
| 49 | 1.2.2.7 | **36) New Probe head mount** | 59d? | 2004-01-19 | 2004-04-08 |  |  |  | 55d |  |  |  | 704h |  |  |
| 50 | 1.2.2.7.1 | 37) Design | 20d? | 2004-01-19 | 2004-02-13 |  |  |  | 124d | 0d |  | Mark Brown | 160h |  |  |
| 51 | 1.2.2.7.2 | 38) Build | 15d? | 2004-02-16 | 2004-03-05 | 50 |  |  | 124d | 0d |  | Mark Brown; Jonnhy F | 240h |  |  |
| 52 | 1.2.2.7.3 | 39) Assemble | 10d? | 2004-03-08 | 2004-03-19 | 51 |  |  | 124d | 0d |  | Johnny F | 80h |  |  |
| 53 | 1.2.2.7.4 | 40) Vertical testing | 8d? | 2004-03-22 | 2004-03-31 | 52 |  |  | 124d | 0d |  | Sheri White; Johnny F | 128h |  |  |
| 54 | 1.2.2.7.5 | 41) Test in cold room | 6d? | 2004-04-01 | 2004-04-08 | 53 |  |  | 124d |  |  | Sheri White; Johnnny F | 96h |  |  |
| 55 | 1.2.2.8 | **42) Adjust camera server rate** | 13.5d? | 2004-01-19 | 2004-02-05 |  |  |  | 100.5d |  |  |  | 216h |  |  |
| 56 | 1.2.2.8.1 | 43) Reduce ethernet traffic | 13.5d? | 2004-01-19 | 2004-02-05 |  |  |  | 169.5d |  |  | Rich Henthorn; Alana Sherman | 216h |  |  |
| 57 | 1.2.2.9 | **44) Z-axis Rt Angle connector** | 49.5d? | 2004-01-19 A | 2004-03-26 |  | 5% | 46.98d? | 64.5d |  |  |  | 456h | 13.4h |  |
| 58 | 1.2.2.9.1 | 45) Review installation | 1d? | 2004-01-19 A | 2004-01-19 |  | 90% | 0.1d? | 182d |  |  |  |  |  |  |
| 59 | 1.2.2.9.2 | 46) Order or Design new mount | 33.5d? | 2004-01-19 A | 2004-03-04 |  | 5% | 31.82d? | 133.5d | 0d |  | Scott Jensen | 268h | 13.4h |  |
| 60 | 1.2.2.9.3 | 47) Installation | 8.5d? | 2004-03-04 | 2004-03-16 | 59 |  |  | 133.5d | 0d |  | EE Tech | 68h |  |  |
| 61 | 1.2.2.9.4 | 48) Test | 7.5d? | 2004-03-17 | 2004-03-26 | 60 |  |  | 133.5d |  |  | Scott Jensen; EE Tech | 120h |  |  |

| ID | WBS | Task | Duration | Start | Finish | Predecessors | Complete | Remaining | Total slack | Free slack | Resources | Work | Actual work | Cost | Actual cost |
| --- | --- | --- | --- | --- | --- | --- | --- | --- | --- | --- | --- | --- | --- | --- | --- |
| 62 | 1.2.2.10 | **49) Swing Arm** | 59d? | 2004-01-19 A | 2004-04-08 |  | 48% | 30.48d? | 55d |  |  | 792h | 228h |  |  |
| 63 | 1.2.2.10.1 | 50) Consult on Design | 24d? | 2004-01-19 A | 2004-02-19 A |  | 100% |  |  |  | Mark Brown | 192h | 192h |  |  |
| 64 | 1.2.2.10.2 | 51) Parts Ordered | 1d? | 2004-02-20 A | 2004-02-20 | 63 | 50% | 0.5d? | 127.5d | 0d |  |  |  |  |  |
| 65 | 1.2.2.10.3 | 52) Build | 15d? | 2004-02-20 A | 2004-03-11 | 64 | 30% | 10.5d? | 124d | 0d | Johnny F | 120h | 36h |  |  |
| 66 | 1.2.2.10.4 | 53) Test | 20d? | 2004-03-12 | 2004-04-08 | 65 |  |  | 124d |  | Johnny F; Buck R; Mark B | 480h |  |  |  |
| 68 | 1.2.2.11 | **54) Rigid Lift Frame Mod** | 1d? | 2004-01-19 | 2004-01-19 |  |  |  | 113d |  |  |  |  |  |  |
| 69 | 1.2.2.11.1 | 55) Design | 1d? | 2004-01-19 | 2004-01-19 |  |  |  | 182d |  |  |  |  |  |  |
| 70 | 1.2.2.11.2 | 56) Purchase Mat'l | 1d? | 2004-01-19 | 2004-01-19 |  |  |  | 182d |  |  |  |  |  |  |
| 71 | 1.2.2.11.3 | 57) Build | 1d? | 2004-01-19 | 2004-01-19 |  |  |  | 182d |  |  |  |  |  |  |
| 72 | 1.2.2.11.4 | 58) Test w/ pilots | 1d? | 2004-01-19 | 2004-01-19 |  |  |  | 182d |  |  |  |  |  |  |
| 73 | 1.3 | **Upgrades** | 114d? | 2004-01-19 A | 2004-06-24 |  | 1% | 112.88d? | 69d |  |  | 3904h | 19.99h | 106,950 | 6,609.5 |
| 74 | 1.3.1 | **59) Purchase new components** | 46d? | 2004-01-19 A | 2004-03-22 |  | 2% | 45.22d? | 137d |  |  | 1104h | 18.96h | 66,950 | 6,609.5 |
| 75 | 1.3.1.1 | 60) USB CCD camera | 46d? | 2004-01-19 A | 2004-03-22 |  | 1% | 45.54d? | 137d |  | Sheri W | 368h | 3.68h | 27,000 | 270 |
| 76 | 1.3.1.2 | 61) MR Probe head | 46d? | 2004-01-19 A | 2004-03-22 |  | 1% | 45.54d? | 137d |  | Sheri W | 368h | 3.68h | 9,950 | 99.5 |
| 77 | 1.3.1.3 | 62) Titanium immersion probe | 1d? | 2004-01-19 A | 2004-01-19 A |  | 100% |  |  |  | Sheri W | 8h | 8h | 6,000 | 6,000 |
| 78 | 1.3.1.4 | 63) 532 nm laser | 45d? | 2004-01-19 A | 2004-03-19 |  | 1% | 44.55d? | 138d |  | Sheri W | 360h | 3.6h | 24,000 | 240 |
| 80 | 1.3.1.5 | 63b) Neon Bulb | 1d? | 2004-01-19 | 2004-01-19 |  |  |  | 113d |  |  |  |  |  |  |
| 81 | 1.3.2 | **DORISS upgrades** | 114d? | 2004-01-19 A | 2004-06-24 |  | 1% | 113.26d? | 0d |  |  | 2800h | 1.03h | 20,000 |  |
| 82 | 1.3.2.1 | **64) Fiber cable Assy** | 1d? | 2004-01-19 A | 2004-01-19 |  | 1% | 0.99d? | 113d |  |  | 8h | 0.08h |  |  |
| 83 | 1.3.2.1.1 | 65) Risk mitigation plan | 1d? | 2004-01-19 A | 2004-01-19 |  | 1% | 0.99d? | 182d |  | Sheri White | 8h | 0.08h |  |  |
| 84 | 1.3.2.1.2 | 66) Research options | 1d? | 2004-01-19 A | 2004-01-19 |  | 1% | 0.99d? | 182d |  |  |  |  |  |  |
| 85 | 1.3.2.1.3 | 67) Design | 1d? | 2004-01-19 A | 2004-01-19 |  | 1% | 0.99d? | 182d |  |  |  |  |  |  |
| 86 | 1.3.2.1.4 | 68) Purchase cable / connectors | 1d? | 2004-01-19 A | 2004-01-19 |  | 1% | 0.99d? | 182d |  |  |  |  |  |  |
| 87 | 1.3.2.1.5 | 69) Build in-house components | 1d? | 2004-01-19 A | 2004-01-19 |  | 1% | 0.99d? | 182d |  |  |  |  |  |  |
| 88 | 1.3.2.1.6 | 70) Assy | 1d? | 2004-01-19 A | 2004-01-19 |  | 1% | 0.99d? | 182d |  |  |  |  |  |  |
| 89 | 1.3.2.1.7 | 71) Test | 1d? | 2004-01-19 A | 2004-01-19 |  | 1% | 0.99d? | 182d |  |  |  |  |  |  |
| 90 | 1.3.2.1.8 | 72) Integration | 1d? | 2004-01-19 A | 2004-01-19 |  | 1% | 0.99d? | 182d |  |  |  |  |  |  |
| 91 | 1.3.2.1.9 | 73) Tank and Cold Rm test | 1d? | 2004-01-19 A | 2004-01-19 |  | 1% | 0.99d? | 182d |  |  |  |  |  |  |
| 92 | 1.3.2.1.10 | 74) Sea trials | 1d? | 2004-01-19 A | 2004-01-19 |  | 1% | 0.99d? | 182d |  |  |  |  |  |  |

| ID | WBS | Task | Duration | Start | Finish | Predecessors | Complete | Remaining | Total slack | Free slack | Resources | Work | Actual work | Cost |
| --- | --- | --- | --- | --- | --- | --- | --- | --- | --- | --- | --- | --- | --- | --- |
| 93 | 1.3.2.2 | **75) PC Upgrade** | 1d? | 2004-01-19 A | 2004-01-19 |  | 25% | 0.75d? | 113d |  |  |  |  |  |
| 94 | 1.3.2.2.1 | 76) Research Components | 1d? | 2004-01-19 A | 2004-01-19 A |  | 100% |  |  |  |  |  |  |  |
| 95 | 1.3.2.2.2 | 77) Purchase | 1d? | 2004-01-19 A | 2004-01-19 |  | 50% | 0.5d? | 182d |  |  |  |  |  |
| 96 | 1.3.2.2.3 | 78) Assy | 1d? | 2004-01-19 | 2004-01-19 |  |  |  | 182d |  |  |  |  |  |
| 97 | 1.3.2.2.4 | 79) Test | 1d? | 2004-01-19 | 2004-01-19 |  |  |  | 182d |  |  |  |  |  |
| 98 | 1.3.2.2.5 | 80) Integrate w/ DORISS | 1d? | 2004-01-19 | 2004-01-19 |  |  |  | 182d |  |  |  |  |  |
| 99 | 1.3.2.2.6 | 81) Intergration testing | 1d? | 2004-01-19 | 2004-01-19 |  |  |  | 182d |  |  |  |  |  |
| 100 | 1.3.2.3 | **82) New optical bench** | 114d? | 2004-01-19 A | 2004-06-24 |  |  | 113.9d? | 0d |  |  | 1588h | 0.95h | 20,000 |
| 101 | 1.3.2.3.1 | 83) Concept review for single can | 11d? | 2004-01-19 A | 2004-02-02 |  | 1% | 10.89d? | 172d |  |  | 100h | 0.95h |  |
| 102 | 1.3.2.3.2 | 84) design | 30d? | 2004-01-19 | 2004-02-27 |  |  |  | 0d |  | Bill K | 240h |  |  |
| 103 | 1.3.2.3.3 | 85) PDR | 8d? | 2004-03-01 | 2004-03-10 | 102 |  |  | 0d |  | Bill K | 64h |  |  |
| 104 | 1.3.2.3.4 | 86) build | 6.5d? | 2004-03-11 | 2004-03-19 | 103 |  |  | 0d |  | ?? | 52h |  | 20,000 |
| 105 | 1.3.2.3.5 | 87) bench assembly | 13d? | 2004-03-19 | 2004-04-07 | 104 |  |  | 0d |  | Bill K; Sheri W | 208h |  |  |
| 106 | 1.3.2.3.6 | 88) test | 10d? | 2004-04-07 | 2004-04-21 | 105 |  |  | 0d |  | Sheri W; Bill K; Alana Sherman | 240h |  |  |
| 107 | 1.3.2.3.7 | 89) housing mods | 7.5d? | 2004-04-21 | 2004-04-30 | 106 |  |  | 0d |  | Bill K | 60h |  |  |
| 108 | 1.3.2.3.8 | 90) optical sub-assembly | 9.5d? | 2004-05-03 | 2004-05-14 | 107 |  |  | 0d |  | Sheri W; Alana Sherman | 152h |  |  |
| 109 | 1.3.2.3.9 | 91) sub-system test | 9.5d? | 2004-05-14 | 2004-05-27 | 108 |  |  | 0d |  | Sheri W; Alana Sherman | 152h |  |  |
| 110 | 1.3.2.3.10 | 92) optical sys complete test | 9d? | 2004-05-28 | 2004-06-09 | 109 |  |  | 0d |  | Sheri W; Alana Sherman | 144h |  |  |
| 111 | 1.3.2.3.11 | 93) tank test | 11d? | 2004-06-10 | 2004-06-24 | 110 |  |  | 0d |  | Sheri W; Alana Sherman | 176h |  |  |
| 112 | 1.3.2.4 | **94) New Housings** | 90d? | 2004-01-19 | 2004-05-21 |  |  |  | 24d |  |  | 1204h |  |  |
| 113 | 1.3.2.4.1 | **95) Spectrometer housing** | 52d? | 2004-03-11 | 2004-05-21 |  |  |  | 24d |  |  | 544h |  |  |
| 114 | 1.3.2.4.1.1 | 96) design | 12d? | 2004-03-11 | 2004-03-26 | 103 |  |  | 93d | 0d | Mark Brown | 96h |  |  |
| 115 | 1.3.2.4.1.2 | 97) review | 14d? | 2004-03-29 | 2004-04-15 | 114 |  |  | 93d | 0d | Mark Brown | 112h |  |  |
| 116 | 1.3.2.4.1.3 | 98) build | 9d? | 2004-04-16 | 2004-04-28 | 115 |  |  | 93d | 0d | Mark Brown; Johnny F | 144h |  |  |
| 117 | 1.3.2.4.1.4 | 99) assemble | 10d? | 2004-04-29 | 2004-05-12 | 116 |  |  | 93d | 0d | Johnny F | 80h |  |  |
| 118 | 1.3.2.4.1.5 | 100) test | 7d? | 2004-05-13 | 2004-05-21 | 117 |  |  | 93d |  | Mark Brown; Johnny F | 112h |  |  |

| ID | WBS | Task | Duration | Start | Finish | Predecessors | Complete | Remaining | Total slack | Free slack | Resources | Work | Actual work | Cost |
| --- | --- | --- | --- | --- | --- | --- | --- | --- | --- | --- | --- | --- | --- | --- |
| 119 | 1.3.2.4.2 | **101) Probe Head housing** | 70d? | 2004-01-19 | 2004-04-23 |  |  |  | 44d |  |  | 660h |  |  |
| 120 | 1.3.2.4.2.1 | 102) design | 24d? | 2004-01-19 | 2004-02-19 |  |  |  | 113d | 0d | Mark Brown | 192h |  |  |
| 121 | 1.3.2.4.2.2 | 103) review | 15d? | 2004-02-20 | 2004-03-11 | 120 |  |  | 113d | 0d | Mark Brown | 120h |  |  |
| 122 | 1.3.2.4.2.3 | 104) build | 9d? | 2004-03-12 | 2004-03-24 | 121 |  |  | 113d | 0d | Johnny F | 72h |  |  |
| 123 | 1.3.2.4.2.4 | 105) assemble | 9.5d? | 2004-03-25 | 2004-04-07 | 122 |  |  | 113d | 0d | Johnny F | 76h |  |  |
| 124 | 1.3.2.4.2.5 | 106) test | 12.5d? | 2004-04-07 | 2004-04-23 | 123 |  |  | 113d |  | Mark Brown; Johnny F | 200h |  |  |
| 125 | 1.3.3 | **PUP upgrades** | 1d? | 2004-01-19 | 2004-01-19 |  |  |  | 113d |  |  |  |  | 20,000 |
| 126 | 1.3.3.1 | **107) Pan and Tilt Axis - 2 axis of freedom** | 1d? | 2004-01-19 | 2004-01-19 |  |  |  | 113d |  |  |  |  | 20,000 |
| 127 | 1.3.3.1.1 | 108) Concept design | 1d? | 2004-01-19 | 2004-01-19 |  |  |  | 182d |  |  |  |  |  |
| 128 | 1.3.3.1.2 | 109) Verify electronics space availability | 1d? | 2004-01-19 | 2004-01-19 |  |  |  | 182d |  |  |  |  |  |
| 129 | 1.3.3.1.3 | 110) Concept review | 1d? | 2004-01-19 | 2004-01-19 |  |  |  | 182d |  |  |  |  |  |
| 130 | 1.3.3.1.4 | 111) Design | 1d? | 2004-01-19 | 2004-01-19 |  |  |  | 182d |  |  |  |  |  |
| 131 | 1.3.3.1.5 | 112) PDR for P&T | 1d? | 2004-01-19 | 2004-01-19 |  |  |  | 182d |  |  |  |  |  |
| 132 | 1.3.3.1.6 | 113) Purchase components | 1d? | 2004-01-19 | 2004-01-19 |  |  |  | 182d |  |  |  |  | 20,000 |
| 133 | 1.3.3.1.7 | 114) Build Components | 1d? | 2004-01-19 | 2004-01-19 |  |  |  | 182d |  |  |  |  |  |
| 134 | 1.3.3.1.8 | 115) Sub -Assy | 1d? | 2004-01-19 | 2004-01-19 |  |  |  | 182d |  |  |  |  |  |
| 135 | 1.3.3.1.9 | 116) Sub-Assy test | 1d? | 2004-01-19 | 2004-01-19 |  |  |  | 182d |  |  |  |  |  |
| 136 | 1.3.3.1.10 | 117) P&T integration to PUP | 1d? | 2004-01-19 | 2004-01-19 |  |  |  | 182d |  |  |  |  |  |
| 137 | 1.3.3.1.11 | 118) P&T Tank Testing | 1d? | 2004-01-19 | 2004-01-19 |  |  |  | 182d |  |  |  |  |  |
| 138 | 1.3.3.1.12 | 119) P&T Cold Testing | 1d? | 2004-01-19 | 2004-01-19 |  |  |  | 182d |  |  |  |  |  |
| 139 | 1.3.3.1.13 | 120) P&T Sea Trials | 1d? | 2004-01-19 | 2004-01-19 |  |  |  | 182d |  |  |  |  |  |
| 141 | 1.4 | **Cruises** | 1d? | 2004-01-19 A | 2004-01-19 |  | 8% | 0.92d? | 113d |  |  | 32h | 3.84h |  |
| 142 | 1.4.1 | **121) March 17-18 - Ventana** | 1d? | 2004-01-19 A | 2004-01-19 |  | 11% | 0.89d? | 113d |  | Ventana | 8h | 1.6h |  |
| 143 | 1.4.1.1 | 121a) MOB - Doriss/PUP on Ventana - March 16th | 1d? | 2004-01-19 | 2004-01-19 |  |  |  | 113d |  |  |  |  |  |
| 144 | 1.4.1.2 | 121b) Cruise Configuration - readiness in Lab 3/12 & 15 | 1d? | 2004-01-19 | 2004-01-19 |  |  |  | 113d |  |  |  |  |  |
| 145 | 1.4.1.3 | 121c) System Cold Test 3/11 | 1d? | 2004-01-19 | 2004-01-19 |  |  |  | 113d |  |  |  |  |  |
| 146 | 1.4.1.4 | 121d) System Tank Test - 3/10 | 1d? | 2004-01-19 | 2004-01-19 |  |  |  | 113d |  |  |  |  |  |
| 147 | 1.4.1.5 | 121e) System Lab Test 3/9 | 1d? | 2004-01-19 | 2004-01-19 |  |  |  | 113d |  |  |  |  |  |
| 148 | 1.4.1.6 | 121f) Calibrate and Test Doriss 3/8 | 1d? | 2004-01-19 | 2004-01-19 |  |  |  | 113d |  |  |  |  |  |
| 149 | 1.4.1.7 | 121g) Seal Housings and Vacuum Check 3/5 | 1d? | 2004-01-19 | 2004-01-19 |  |  |  | 113d |  |  |  |  |  |
| 150 | 1.4.1.8 | 121h) Bench Test DORISS and PUP prior to clsoing housings 3/4 | 1d? | 2004-01-19 | 2004-01-19 |  |  |  | 113d |  |  |  |  |  |
| 151 | 1.4.1.9 | 121i) Develop Cruise Plans | 1d? | 2004-01-19 A | 2004-01-19 A |  | 100% |  |  |  |  |  |  |  |

| ID | WBS | Task | Duration | Start | Finish | Total slack | Resources | Work | Actual work |
| --- | --- | --- | --- | --- | --- | --- | --- | --- | --- |
| 152 | 1.4.2 | **122) March 19-22 - Ventana** | 1d? | 2004-01-19 | 2004-01-19 | 113d | Ventana | 8h | 1.2h |
| 153 | 1.4.2.1 | 122a) MOB for Part II of Cruise 3/19 | 1d? | 2004-01-19 | 2004-01-19 | 113d |  |  |  |
| 154 | 1.4.2.2 | 122b) Bubble Box Prep | 1d? | 2004-01-19 | 2004-01-19 | 113d |  |  |  |
| 155 | 1.4.3 | **123) July 14-26 - Tiburon / Hydrate Ridge** | 1d? | 2004-01-19 | 2004-01-19 | 113d | Tiburon | 8h | 1.04h |
| 156 | 1.4.3.1 | Dive Plan | 1d? | 2004-01-19 | 2004-01-19 | 113d |  |  |  |
| 157 | 1.4.4 | **124) Sept 27-28 - Ventana** | 1d? | 2004-01-19 | 2004-01-19 | 113d | Ventana | 8h |  |
| 158 | 1.4.4.1 | Ed checking | 1d? | 2004-01-19 | 2004-01-19 | 113d |  |  |  |
